# Order 65511 Bell PO# 219520 061804test

How a schedule from MS Project changed from version to version. A marks actual dates.

## Version 1 (saved 2004-11-08, file VVSA MTM Schedule 20041105.mpp)

| ID | WBS | Task | Duration | Start | Finish | Total float | Constraint |
| --- | --- | --- | --- | --- | --- | --- | --- |
| 1 |  | Submit Proposal | 0d | 2004-07-22 | 2004-07-22 | 0d | start no later than 2004-07-22 |
| 2 |  | Teleconference to discuss Proposal | 5d | 2004-07-26 | 2004-07-30 | 2d | start no later than 2004-07-26 |
| 3 |  | Receive Order | 1d | 2004-08-31 | 2004-08-31 | 28d | finish no later than 2004-08-31 |
| 4 | 4 | **Start Up/Engineering LI#1** | 75d | 2004-08-31 | 2004-12-13 | 28d | as late as possible |
| 5 |  | Process Order | 75d | 2004-08-31 | 2004-12-13 | 28d | start no later than 2004-08-31 |
| 6 | 5 | **Special Tooling LI# 2** | 108d | 2004-07-22 | 2004-12-20 | 0d | as late as possible |
| 7 | 5.1 | **Dies** | 76d | 2004-09-06 | 2004-12-20 | 32d | as late as possible |
| 8 |  | Engineering | 35d | 2004-09-06 | 2004-10-22 | 32d | start no later than 2004-09-06 |
| 9 |  | Procure Materials (4 sets) | 6w | 2004-09-13 | 2004-10-22 | 37d | start no later than 2004-09-13 |
| 10 |  | Machine Complete | 8w | 2004-10-08 | 2004-12-02 | 56d | start no later than 2004-10-08 |
| 11 |  | Deburr | 4d | 2004-12-02 | 2004-12-07 | 95d | start no later than 2004-12-02 |
| 12 |  | Inspection | 9d | 2004-12-08 | 2004-12-20 | 99d | start no later than 2004-12-08 |
| 13 | 5.2 | **Fixtures (2) 60 degree** | 67d | 2004-09-06 | 2004-12-07 | 32d | as late as possible |
| 14 |  | Engineering | 45d | 2004-09-06 | 2004-11-05 | 32d | start no later than 2004-09-06 |
| 15 |  | Procure Materials | 4w | 2004-09-13 | 2004-10-08 | 37d | start no later than 2004-09-13 |
| 16 |  | Machine Complete | 6w | 2004-10-11 | 2004-11-19 | 57d | start no later than 2004-10-11 |
| 17 |  | Assemble | 1w | 2004-11-22 | 2004-11-26 | 87d | start no later than 2004-11-22 |
| 18 |  | Deburr | 3d | 2004-11-26 | 2004-11-30 | 91d | start no later than 2004-11-26 |
| 19 |  | Inspection | 5d | 2004-12-01 | 2004-12-07 | 94d | start no later than 2004-12-01 |
| 20 | 5.3 | **Fixture (1) 120 degree** | 0d | 2004-07-22 | 2004-07-22 | 0d | as late as possible |
| 21 |  | Engineering | 0d | 2004-07-22 | 2004-07-22 | 0d | start no later than 2004-07-22 |
| 22 |  | Procure Materials | 0d | 2004-07-22 | 2004-07-22 | 0d | start no later than 2004-07-22 |
| 23 |  | Machine Complete | 0d | 2004-07-22 | 2004-07-22 | 0d | start no later than 2004-07-22 |
| 24 |  | Assemble | 0d | 2004-07-22 | 2004-07-22 | 0d | start no later than 2004-07-22 |
| 25 |  | Deburr | 0d | 2004-07-22 | 2004-07-22 | 0d | start no later than 2004-07-22 |
| 26 |  | Inspection | 0d | 2004-07-22 | 2004-07-22 | 0d | start no later than 2004-07-22 |
| 27 |  | Procure Vessel Material | 1d? | 2004-07-22 | 2004-07-22 | 0d | finish no later than 2004-07-22 |
| 28 |  | Development Panels (9 panels) | 0d | 2005-10-28 | 2005-10-28 | 332d | as late as possible |
| 29 |  | Production Panels (9-18 panels) | 0d | 2005-10-28 | 2005-10-28 | 332d | as late as possible |
| 30 |  | Production Panels (36-45 panels) | 0d | 2005-10-28 | 2005-10-28 | 332d | as late as possible |
| 31 | 10 | **First 120 deg seg LI #3** | 162d | 2005-01-20 | 2005-09-05 | 131d | as late as possible |
| 32 |  | 1st 60 deg segment | 65d | 2005-01-20 | 2005-04-21 | 131d | start no later than 2005-01-20 |
| 33 |  | 2nd 60 deg segment | 39d | 2005-02-28 | 2005-04-21 | 157d | start no later than 2005-02-28 |
| 34 |  | Join two pieces | 20d | 2005-04-21 | 2005-05-19 | 196d | start no later than 2005-04-21 |
| 35 |  | Machine for Ports | 14d | 2005-05-19 | 2005-06-08 | 216d | start no later than 2005-05-19 |
| 36 |  | Weld Ports | 15d | 2005-06-08 | 2005-06-29 | 230d | start no later than 2005-06-08 |
| 37 |  | Final Machine | 17d | 2005-06-29 | 2005-07-22 | 245d | start no later than 2005-06-29 |
| 38 |  | Vacuum Test | 10d | 2005-07-22 | 2005-08-05 | 262d | start no later than 2005-07-22 |
| 39 |  | Cut Off Ports | 15d | 2005-08-05 | 2005-08-26 | 272d | start no later than 2005-08-05 |
| 40 |  | Pack for Shipping LI#4 | 4d | 2005-08-26 | 2005-09-01 | 287d | start no later than 2005-08-26 |
| 41 |  | Receive at PPPL | 2d | 2005-09-01 | 2005-09-05 | 291d | start no later than 2005-09-01 |
| 42 | 11 | **Second 120 deg seg LI# 3** | 108d | 2005-04-21 | 2005-09-20 | 196d | as late as possible |
| 43 |  | 60 deg segment | 35d | 2005-04-21 | 2005-06-09 | 196d | start no later than 2005-04-21 |
| 44 |  | 60 deg segment | 35d | 2005-04-21 | 2005-06-09 | 196d | start no later than 2005-04-21 |
| 45 |  | Join two pieces | 12d | 2005-06-09 | 2005-06-27 | 231d | start no later than 2005-06-09 |
| 46 |  | Machine for Ports | 10d | 2005-06-27 | 2005-07-11 | 243d | start no later than 2005-06-27 |
| 47 |  | Weld Ports | 17d | 2005-07-11 | 2005-08-03 | 253d | start no later than 2005-07-11 |
| 48 |  | Final Machine | 12d | 2005-08-03 | 2005-08-19 | 270d | start no later than 2005-08-03 |
| 49 |  | Vacuum Test | 5d | 2005-08-19 | 2005-08-26 | 282d | start no later than 2005-08-19 |
| 50 |  | Cut Off Ports | 12d | 2005-08-26 | 2005-09-13 | 287d | start no later than 2005-08-26 |
| 51 |  | Pack for Shipping LI#4 | 3d | 2005-09-13 | 2005-09-16 | 299d | start no later than 2005-09-13 |
| 52 |  | Receive at PPPL | 2d | 2005-09-16 | 2005-09-20 | 302d | start no later than 2005-09-16 |
| 53 | 12 | **Third 120 deg seg LI# 3** | 101d? | 2005-06-09 | 2005-10-28 | 231d | as late as possible |
| 54 |  | 60 deg segment | 35d | 2005-06-09 | 2005-07-28 | 231d | start no later than 2005-06-09 |
| 55 |  | 60 deg segment | 35d | 2005-06-09 | 2005-07-28 | 231d | start no later than 2005-06-09 |
| 56 |  | Join two pieces | 10d | 2005-07-28 | 2005-08-11 | 266d | start no later than 2005-07-28 |
| 57 |  | Machine for Ports | 8d | 2005-08-11 | 2005-08-23 | 276d | start no later than 2005-08-11 |
| 58 |  | Weld Ports | 15d | 2005-08-23 | 2005-09-13 | 284d | start no later than 2005-08-23 |
| 59 |  | Final Machine | 10d | 2005-09-13 | 2005-09-27 | 299d | start no later than 2005-09-13 |
| 60 |  | Vacuum Test | 5d | 2005-09-27 | 2005-10-04 | 309d | start no later than 2005-09-27 |
| 61 |  | Cut Off Ports | 10d | 2005-10-04 | 2005-10-18 | 314d | start no later than 2005-10-04 |
| 62 |  | Pack for Shipping LI#4 | 3d | 2005-10-18 | 2005-10-21 | 324d | start no later than 2005-10-18 |
| 63 |  | Receive at PPPL | 2d | 2005-10-21 | 2005-10-25 | 327d | start no later than 2005-10-21 |
| 64 |  | Pack for PPPL Tooling | 1d? | 2005-10-28 | 2005-10-28 | 331d | as late as possible |
| 65 |  | Receive at PPPL Tooling | 1d? | 2005-10-28 | 2005-10-28 | 331d | as late as possible |

## Version 2 (saved 2004-11-08, file VVSA MTM Schedule 20041108 MV.mpp)

Last finish stays 2005-10-28. Complete tasks 0 → 3.

Changed:

| ID | Task | Start | Finish | Complete | Total float |
| --- | --- | --- | --- | --- | --- |
| 1 | Submit Proposal | 2004-07-22 A | 2004-07-22 A | 0% → 100% | 0d → none |
| 2 | Teleconference to discuss Proposal | 2004-07-26 A | 2004-07-30 A | 0% → 100% | 2d → none |
| 3 | Receive Order | 2004-08-31 A | 2004-08-31 A | 0% → 100% | 28d → none |
| 4 | **Start Up/Engineering LI#1** | 2004-08-31 A |  | 0% → 50% | 28d → 0d |
| 5 | Process Order | 2004-08-31 A |  | 0% → 50% | 28d → 0d |
| 6 | **Special Tooling LI# 2** | 2004-07-22 A |  | 0% → 8% | 0d → 31d |
| 7 | **Dies** | 2004-09-06 A |  | 0% → 11% | 32d → 41d |
| 8 | Engineering | 2004-09-06 A |  | 0% → 20% | 32d → 0d |
| 9 | Procure Materials (4 sets) | 2004-09-13 A |  | 0% → 20% | 37d → 0d |
| 13 | **Fixtures (2) 60 degree** | 2004-09-06 A |  | 0% → 4% | 32d → 22d |
| 14 | Engineering | 2004-09-06 A |  | 0% → 10% | 32d → 0d |

## Version 3 (saved 2004-11-08, file VVSA MTM Schedule 20041108 MV play.mpp)

Last finish stays 2005-10-28.

Changed:

| ID | Task | Total float | Predecessors |
| --- | --- | --- | --- |
| 35 | Machine for Ports | 216d → 196d | none → 34 |
| 45 | Join two pieces |  | none → 35 |
| 46 | Machine for Ports | 243d → 197d | none → 45 |
| 56 | Join two pieces |  | none → 46 |
| 57 | Machine for Ports |  | none → 56 |

## Version 4 (saved 2004-11-09, file VVSA Schedule 20041109.mpp)

Last finish stays 2005-10-28. Complete tasks 3 → 0.

Added:

| ID | Task | Duration | Start | Finish | Constraint |
| --- | --- | --- | --- | --- | --- |
| 6 | Sect 5.1.3 Proc Outline & Asc Procedures | 1d? | 2004-07-22 | 2004-07-22 | finish no later than 2004-07-22 |
| 10 | Sect 5.1 Segmentation Scheme | 2d? | 2005-10-27 | 2005-10-28 | start no later than 2005-10-27 |
| 29 | Sect 5.1.2 Fiducials | 1d? | 2004-07-22 | 2004-07-22 | finish no later than 2004-07-22 |

Changed:

| ID | Task | Start | Finish | Duration | Complete | Total float | Predecessors |
| --- | --- | --- | --- | --- | --- | --- | --- |
| 1 | Submit Proposal | 2004-07-22 A → 2004-07-22 | 2004-07-22 A → 2004-07-22 |  | 100% → 0% | none → 0d |  |
| 2 | Teleconference to discuss Proposal | 2004-07-26 A → 2004-07-26 | 2004-07-30 A → 2004-07-30 |  | 100% → 0% | none → 2d |  |
| 3 | Receive Order | 2004-08-31 A → 2004-08-31 | 2004-08-31 A → 2004-08-31 |  | 100% → 0% | none → 28d |  |
| 4 | **Start Up/Engineering LI#1** | 2004-08-31 A → 2004-07-22 (-40d) |  | 75d → 103d? | 50% → 0% |  |  |
| 5 | Process Order | 2004-08-31 A → 2004-08-31 |  |  | 50% → 0% | 0d → 28d |  |
| 7 | **Special Tooling LI# 2** | 2004-07-22 A → 2004-07-22 | 2004-12-20 → 2005-10-28 (+312d) | 108d → 332d? | 8% → 0% | 31d → 0d |  |
| 8 | **Dies** | 2004-09-06 A → 2004-09-06 | 2004-12-20 → 2005-10-28 (+312d) | 76d → 300d? | 11% → 0% | 41d → 32d |  |
| 9 | Engineering | 2004-09-06 A → 2004-09-06 |  |  | 20% → 0% | 0d → 32d |  |
| 11 | Procure Materials (4 sets) | 2004-09-13 A → 2004-09-13 |  |  | 20% → 0% | 0d → 37d |  |
| 15 | **Fixtures (2) 60 degree** | 2004-09-06 A → 2004-09-06 |  |  | 4% → 0% | 22d → 32d |  |
| 16 | Engineering | 2004-09-06 A → 2004-09-06 |  |  | 10% → 0% | 0d → 32d |  |
| 38 | Machine for Ports |  |  |  |  | 196d → 216d | 37 → none |
| 48 | Join two pieces |  |  |  |  |  | 38 → none |
| 49 | Machine for Ports |  |  |  |  | 197d → 243d | 48 → none |
| 59 | Join two pieces |  |  |  |  |  | 49 → none |
| 60 | Machine for Ports |  |  |  |  |  | 59 → none |

## Version 5 (saved 2004-11-12, file VVSA Schedule 20041109 MV1.mpp)

Last finish stays 2005-10-28. Complete tasks 0 → 3.

Changed:

| ID | Task | Start | Finish | Complete | Total float |
| --- | --- | --- | --- | --- | --- |
| 1 | Submit Proposal | 2004-07-22 A | 2004-07-22 A | 0% → 100% | 0d → none |
| 2 | Teleconference to discuss Proposal | 2004-07-26 A | 2004-07-30 A | 0% → 100% | 2d → none |
| 3 | Receive Order | 2004-08-31 A | 2004-08-31 A | 0% → 100% | 28d → none |
| 4 | **Start Up/Engineering LI#1** | 2004-07-22 A |  | 0% → 20% |  |
| 5 | Process Order | 2004-08-31 A |  | 0% → 20% | 28d → 0d |
| 6 | Sect 5.1.3 Proc Outline & Asc Procedures | 2004-07-22 A |  | 0% → 10% |  |
| 7 | **Special Tooling LI# 2** | 2004-07-22 A |  | 0% → 1% | 0d → 255d |
| 8 | **Dies** | 2004-09-06 A |  | 0% → 1% | 32d → 265d |
| 9 | Engineering | 2004-09-06 A |  | 0% → 5% | 32d → 0d |
| 15 | **Fixtures (2) 60 degree** | 2004-09-06 A |  | 0% → 1% | 32d → 22d |
| 16 | Engineering | 2004-09-06 A |  | 0% → 2% | 32d → 0d |
| 22 | **Fixture (1) 120 degree** | 2004-07-22 A |  |  |  |
| 23 | Engineering | 2004-07-22 A |  | 0% → 1% |  |
| 29 | Sect 5.1.2 Fiducials | 2004-07-22 A |  | 0% → 60% |  |
| 30 | Procure Vessel Material | 2004-07-22 A |  | 0% → 5% |  |
